# Proget1

Schedule from MS Project, 2019-10-18 to 2020-01-03, costs in €.

## Calendars

- Standard: Mon-Fri 09:00-13:00, 14:00-18:00; Sat-Sun off.

## Resources

| Resource | Group | Rate |
| --- | --- | --- |
| Analista 1 | Analisi | 62.5 |
| Analista programmatore | Analisi | 50 |
| Programmatore 1 | Programmatori | 37.5 |
| Programmatore 2 | Programmatoriù | 37.5 |
| Programmatore 3 workflow expert | Programmatori | 43.75 |

## Schedule

| ID | Task | Type | Duration | Start | Finish | Predecessors | Total slack | Resources | Work | Cost |
| --- | --- | --- | --- | --- | --- | --- | --- | --- | --- | --- |
| 1 | Interviste |  | 3d | 2019-10-18 | 2019-10-22 |  | 0d | Analista 1 [33%]; Analista programmatore | 31.92h | 1,695 |
| 2 | Analisi/revisione dei requisiti | milestone | 10d | 2019-10-23 | 2019-11-05 | 1 | 0d | Analista programmatore; Analista 1 [33%]; Programmatore 3 workflow expert [50%] | 146.4h | 7,400 |
| 3 | Definizione delle specifiche |  | 5d | 2019-11-06 | 2019-11-12 | 2 | 0d | Analista 1 [33%]; Analista programmatore; Programmatore 3 workflow expert [50%] | 73.2h | 3,700 |
| 4 | Revisione del database |  | 2.5d | 2019-11-13 | 2019-11-15 | 3 | 0d | Analista programmatore; Programmatore 1 | 40h | 1,750 |
| 5 | Progettazione dei ruoli utente e sicurezza | milestone | 3d | 2019-11-15 | 2019-11-20 | 4 | 4.5d | Analista programmatore; Programmatore 1; Programmatore 2 | 72h | 3,000 |
| 6 | Costruzione dell'interfaccia utente |  | 7d | 2019-11-18 | 2019-11-26 | 4SS+3d | 0d | Programmatore 2; Programmatore 3 workflow expert [50%]; Programmatore 1 | 140h | 5,425 |
| 7 | Test funzionamento | milestone | 5d | 2019-11-20 | 2019-11-26 | 4FF+3d, 6FF, 5FF | 0d | Programmatore 1; Programmatore 2 | 80h | 3,000 |
| 8 | Rilascio versione provvisoria | milestone | 2d | 2019-11-27 | 2019-11-28 | 7 | 0d | Programmatore 1; Programmatore 2 | 32h | 1,200 |
| 9 | Istruzione del personale |  | 1d | 2019-11-28 | 2019-11-28 | 6FS+1d | 26d | Analista programmatore | 8h | 400 |
| 10 | Raccolta dei feedback |  | 5d | 2019-11-29 | 2019-12-05 | 8 | 0d | Analista 1 [33%]; Analista programmatore; Programmatore 3 workflow expert [50%] | 73.2h | 3,700 |
| 11 | Analisi/revisione dei requisiti |  | 4d | 2019-12-06 | 2019-12-11 | 10SS+5d | 0d | Analista 1 [33%]; Analista programmatore; Programmatore 3 workflow expert [50%] | 58.56h | 2,960 |
| 12 | Definizione delle specifiche | milestone | 2d | 2019-12-12 | 2019-12-13 | 11 | 0d | Analista programmatore | 16h | 800 |
| 13 | Revisione del database |  | 3d | 2019-12-16 | 2019-12-18 | 12 | 0d | Programmatore 2 | 24h | 900 |
| 14 | Progettazione dei ruoli utente e sicurezza |  | 1d | 2019-12-19 | 2019-12-19 | 13 | 0d | Programmatore 2 | 8h | 300 |
| 15 | Costruzione dell'interfaccia utente |  | 3d | 2019-12-17 | 2019-12-19 | 13SS+1d | 0d | Programmatore 1; Programmatore 3 workflow expert [50%] | 36h | 1,425 |
| 16 | Test funzionamento | milestone | 5d | 2019-12-20 | 2019-12-26 | 13FS+1d, 14, 15 | 0d | Programmatore 1; Programmatore 2 | 80h | 3,000 |
| 17 | Rilascio versione numero N | milestone | 1d | 2019-12-27 | 2019-12-27 | 16 | 0d | Programmatore 2 | 8h | 300 |
| 18 | Istruzione del personale |  | 1d | 2019-12-30 | 2019-12-30 | 17 | 4d | Analista programmatore | 8h | 400 |
| 19 | Manutenzione |  | 7d | 2019-11-29 | 2019-12-09 | 8 | 19d | Programmatore 2 | 56h | 2,100 |
| 20 | Messa in produzione | milestone | 5d | 2019-12-30 | 2020-01-03 | 17 | 0d | Programmatore 1; Programmatore 2; Programmatore 3 workflow expert [50%] | 100h | 3,875 |
